# Process to Receive Building Permit

Schedule from MS Project, 2007-01-19 to 2007-12-31, scheduled back from the finish.
CSU

## Calendars

- Standard: Mon-Fri 08:00-12:00, 13:00-17:00; Sat-Sun off.

## Resources

| Resource |
| --- |
| dependent on approval of annexation? |
| dependent on approval of CC? |
| Owner |

## Schedule

| ID | WBS | Task | Type | Duration | Start | Finish | Predecessors | Total slack | Free slack | Constraint | Resources | Text1 |
| --- | --- | --- | --- | --- | --- | --- | --- | --- | --- | --- | --- | --- |
| 1 | 1 | **Preapplication Stage** |  | 52d | 2007-01-19 | 2007-04-02 |  | 0d |  | as late as possible |  |  |
| 2 | 1.1 | Submit Preapplication form | milestone | 0d | 2007-01-19 | 2007-01-19 |  | 0d |  |  | Owner | Owner |
| 3 | 1.2 | Preapplication meeting | milestone | 0d | 2007-01-25 | 2007-01-25 | 2FS+5d | 0d |  |  |  | Owner |
| 4 | 1.3 | LDTC meeting (optional) | milestone | 0d | 2007-02-01 | 2007-02-01 | 3FS+5d | 237d |  |  |  | Planning |
| 5 | 1.4 | Traffic Eng preapp meeting (optional) | milestone | 0d | 2007-02-08 | 2007-02-08 | 3FS+10d | 0d |  |  |  | Owner |
| 6 | 1.5 | Utilities preapp meeting (optional) | milestone | 0d | 2007-02-14 | 2007-02-14 | 5FS+4d | 0d |  |  |  | Owner |
| 7 | 1.6 | City Engineering preapp meeting (optional) | milestone | 0d | 2007-02-19 | 2007-02-19 | 6FS+3d | 0d |  |  |  | Owner |
| 8 | 1.7 | Prepare & Submit Wastewater Master Facilities Report | milestone | 10d | 2007-02-20 | 2007-03-05 | 7 | 80d | 0d |  |  | Owner |
| 9 | 1.8 | Submit Wastewater Master Facilities Report | milestone | 0d | 2007-03-05 | 2007-03-05 | 8 | 80d | 0d |  |  | Owner |
| 10 | 1.9 | Approve Wastewater Master Facilities Report |  | 5d | 2007-03-06 | 2007-03-12 | 9 | 80d |  |  |  | CSU |
| 11 | 1.10 | Neighborhood meeting (optional) | milestone | 0d | 2007-02-15 | 2007-02-15 | 3FS+15d | 227d |  |  |  | Planning |
| 12 | 1.11 | Prepare Formal Application |  | 30d | 2007-02-20 | 2007-04-02 | 5, 6, 7, 3 | 0d |  |  |  | Owner |
| 13 | 2 | **Internal Review Stage- Submittal to Planning** |  | 65d | 2007-04-02 | 2007-07-02 |  | 0d |  | as late as possible |  |  |
| 14 | 2.1 | Submit Formal Application | milestone | 0d | 2007-04-02 | 2007-04-02 | 12 | 0d |  |  |  | Owner |
| 15 | 2.2 | Review Submittal and Issue Review Letter |  | 30d | 2007-04-03 | 2007-05-14 | 14 | 0d |  |  |  | Planning |
| 16 | 2.3 | Revise submittal |  | 10d | 2007-05-15 | 2007-05-28 | 15 | 0d |  |  |  | Owner |
| 17 | 2.4 | Review 2nd Submittal and Issue Review Letter |  | 10d | 2007-05-29 | 2007-06-11 | 16 | 0d |  |  |  | Planning |
| 18 | 2.5 | Revise submittal |  | 5d | 2007-06-12 | 2007-06-18 | 17 | 0d |  |  |  | Owner |
| 19 | 2.6 | Review & Issue Approval Letter or Recommendation to CPC |  | 10d | 2007-06-19 | 2007-07-02 | 18, 10FF | 0d |  |  |  | Planning |
| 20 | 3 | Appear on CPC Agenda (approval of zoning, plat, DP) | milestone | 0d | 2007-07-02 | 2007-07-02 | 19 | 0d |  |  |  | Owner |
| 21 | 4 | Appear on City Council Agenda twice (approval of zoning, plat, DP) | milestone | 0d | 2007-07-02 | 2007-07-02 | 20 | 0d |  |  |  | Owner |
| 22 | 5 | Record plat |  | 10d | 2007-07-03 | 2007-07-16 | 21, 19 | 0d |  | as late as possible |  | Owner |
| 23 | 6 | **Grading** |  | 60d | 2007-03-27 | 2007-06-18 |  | 0d |  | as late as possible |  |  |
| 24 | 6.1 | Prepare and Submit Grading Plan |  | 5d | 2007-03-27 | 2007-04-02 | 14FF | 49d | 0d |  |  | Owner |
| 25 | 6.2 | Receive comments on Grading Plan |  | 15d | 2007-04-03 | 2007-04-23 | 24 | 49d | 0d |  |  | Engineering |
| 26 | 6.3 | Revise and Resubmit Grading Plan |  | 5d | 2007-04-24 | 2007-04-30 | 25 | 49d | 0d |  |  | Owner |
| 27 | 6.4 | Receive Approved Grading Plan |  | 10d | 2007-05-01 | 2007-05-14 | 26 | 49d | 0d |  |  | Engineering |
| 28 | 6.5 | Perform on-site grading work |  | 25d | 2007-05-15 | 2007-06-18 | 27 | 49d | 21d |  |  | Owner |

Notes:
- 20: This will not typically be required for a project of this type but is left in the chart to demonstrate what could occur on other projects.
- 21: This will not typically be required for a project of this type but is left in the chart to demonstrate what could occur on other projects.

| ID | WBS | Task | Type | Duration | Start | Finish | Predecessors | Total slack | Free slack | Constraint | Text1 |
| --- | --- | --- | --- | --- | --- | --- | --- | --- | --- | --- | --- |
| 29 | 7 | **Design Utility Mains and Service Lines** |  | 15d | 2007-05-03 | 2007-05-23 |  | 0d |  | as late as possible |  |
| 30 | 7.1 | Prepare wastewater main line plans |  | 10d | 2007-05-03 | 2007-05-16 | 15FF+2d | 11d | 0d |  | Owner |
| 31 | 7.2 | Prepare water main line plans |  | 10d | 2007-05-03 | 2007-05-16 | 15FF+2d | 11d | 0d |  | Owner |
| 32 | 7.3 | Prepare Utility Service Plan (USP) |  | 2d | 2007-05-17 | 2007-05-18 | 31, 30 | 14d | 3d |  | Owner |
| 33 | 7.4 | Prepare Easements for Main Lines |  | 5d | 2007-05-17 | 2007-05-23 | 30, 31 | 11d | 0d |  | Owner |
| 34 | 8 | **Approval of Utility Addressing Plan by FIMS** |  | 5d | 2007-05-23 | 2007-05-30 |  | 0d |  | as late as possible |  |
| 35 | 8.1 | Submit Utility Addressing Plan to FIMS | milestone | 0d | 2007-05-23 | 2007-05-23 | 33 | 27d | 0d |  | Owner |
| 36 | 8.2 | Assignment of Addresses by Enumerations |  | 3d | 2007-05-24 | 2007-05-28 | 35 | 27d | 0d |  | RBD |
| 37 | 8.3 | FIMS updates database to show lots and addresses |  | 2d | 2007-05-29 | 2007-05-30 | 36 | 27d | 0d |  | CSU |
| 38 | 8.4 | Approval letter with UAP number sent to applicant | milestone | 0d | 2007-05-30 | 2007-05-30 | 37 | 27d | 23d |  | CSU |
| 39 | 9 | **Approval of Wastewater Main Line Plans** |  | 39d | 2007-05-16 | 2007-07-10 |  | 0d |  | as late as possible |  |
| 40 | 9.1 | Submit Wastewater main line plans with easements | milestone | 0d | 2007-05-16 | 2007-05-16 | 30 | 16d | 0d |  | Owner |
| 41 | 9.2 | Review and comment on wastewater main line plans |  | 5d | 2007-05-17 | 2007-05-23 | 40 | 17d | 0d |  | CSU |
| 42 | 9.3 | Revise and Resubmit wastewater main line plans with easements |  | 5d | 2007-05-24 | 2007-05-30 | 41, 33 | 17d | 0d |  | Owner |
| 43 | 9.4 | Review and comment on 2nd submittal wastewater main line plans |  | 5d | 2007-05-31 | 2007-06-06 | 42, 16 | 17d | 0d |  | CSU |
| 44 | 9.5 | Prepare and submit mylars for wastewater main line |  | 5d | 2007-06-07 | 2007-06-13 | 43 | 17d | 13d |  | Owner |
| 45 | 9.6 | Review and sign mylars of wastewater construction drawings |  | 3d | 2007-07-03 | 2007-07-05 | 44, 55, 38, 19 | 4d | 0d |  | CSU |
| 46 | 9.7 | Copies delivered to CSU-Infrastructure Records |  | 3d | 2007-07-06 | 2007-07-10 | 45 | 31d | 3d |  | Owner |
| 47 | 9.8 | **Approval of Easements for Wastewater Main Lines** |  | 21d | 2007-05-23 | 2007-06-21 |  | 0d |  | as late as possible |  |
| 48 | 9.8.1 | Submit Easements for WW Lines- with main line plans | milestone | 0d | 2007-05-23 | 2007-05-23 | 33, 40 | 11d | 0d |  | Owner |
| 49 | 9.8.2 | Dev Services checks easement alignment against main line plans |  | 5d | 2007-05-24 | 2007-05-30 | 48 | 11d | 0d |  | CSU |
| 50 | 9.8.3 | FIMS reviews for closure and signature by proper landowner |  | 3d | 2007-05-31 | 2007-06-04 | 49 | 11d | 0d |  | CSU |
| 51 | 9.8.4 | Easement returned for revision |  | 1d | 2007-06-05 | 2007-06-05 | 50 | 11d | 0d |  | CSU |
| 52 | 9.8.5 | Easement revised and resubmitted with main line plans |  | 2d | 2007-06-06 | 2007-06-07 | 51 | 11d | 0d |  | Owner |
| 53 | 9.8.6 | Dev Services checks easement alignment against main line plans |  | 5d | 2007-06-08 | 2007-06-14 | 52 | 11d | 0d |  | CSU |
| 54 | 9.8.7 | FIMS reviews for closure and signature by proper landowner |  | 3d | 2007-06-15 | 2007-06-19 | 53 | 11d | 0d |  | CSU |
| 55 | 9.8.8 | Record easement and send notification to applicant |  | 2d | 2007-06-20 | 2007-06-21 | 54 | 11d | 7d |  | CSU |

Notes:
- 35: No true predecessor but it is reasonable to perform this step after the design, including easements, is finalized.

| ID | WBS | Task | Type | Duration | Start | Finish | Predecessors | Total slack | Free slack | Constraint | Text1 |
| --- | --- | --- | --- | --- | --- | --- | --- | --- | --- | --- | --- |
| 56 | 10 | **Approval of Water Main Line Plans** |  | 39d | 2007-05-16 | 2007-07-10 |  | 0d |  | as late as possible |  |
| 57 | 10.1 | Submit Water main line plans with easements | milestone | 0d | 2007-05-23 | 2007-05-23 | 33, 31 | 11d | 0d |  | Owner |
| 58 | 10.2 | Submit CAD file for fire flow calcs | milestone | 0d | 2007-05-16 | 2007-05-16 | 31 | 160d | 0d |  | Owner |
| 59 | 10.3 | Prepare and return results of fire flow modeling |  | 3d | 2007-05-17 | 2007-05-21 | 58 | 160d |  |  | CSU |
| 60 | 10.4 | Review and comment on water main line plans |  | 5d | 2007-05-17 | 2007-05-23 | 31 | 14d | 3d |  | CSU |
| 61 | 10.5 | Revise and resubmit water main line plans |  | 5d | 2007-05-29 | 2007-06-04 | 60, 16 | 11d | 0d |  | Owner |
| 62 | 10.6 | Review and comment on 2nd submittal water main line plans |  | 5d | 2007-06-05 | 2007-06-11 | 61 | 11d | 0d |  | CSU |
| 63 | 10.7 | Prepare and submit mylars of water main line plans to Fire Dept |  | 5d | 2007-06-12 | 2007-06-18 | 62 | 11d | 0d |  | Owner |
| 64 | 10.8 | Receive signed mylars from Fire Dept- forward to Dev Services |  | 3d | 2007-06-19 | 2007-06-21 | 63 | 11d | 7d |  | Owner |
| 65 | 10.9 | Review and sign mylars of water construction drawings |  | 3d | 2007-07-03 | 2007-07-05 | 64, 38, 75, 19 | 4d | 0d |  | CSU |
| 66 | 10.10 | Copies delivered to CSU- Infrastructure Records |  | 3d | 2007-07-06 | 2007-07-10 | 65 | 43d | 15d |  | Owner |
| 67 | 10.11 | **Approval of Easements for Water Main Lines** |  | 21d | 2007-05-23 | 2007-06-21 |  | 0d |  | as late as possible |  |
| 68 | 10.11.1 | Submit Easements for Water Lines- with main line plans | milestone | 0d | 2007-05-23 | 2007-05-23 | 33, 57 | 11d | 0d |  | Owner |
| 69 | 10.11.2 | Dev Services checks easement alignment against main line plans |  | 5d | 2007-05-24 | 2007-05-30 | 68 | 11d | 0d |  | CSU |
| 70 | 10.11.3 | FIMS reviews for closure and signature by proper landowner |  | 3d | 2007-05-31 | 2007-06-04 | 69 | 11d | 0d |  | CSU |
| 71 | 10.11.4 | Easement returned for revision |  | 1d | 2007-06-05 | 2007-06-05 | 70 | 11d | 0d |  | CSU |
| 72 | 10.11.5 | Easement revised and resubmitted with main line plans |  | 2d | 2007-06-06 | 2007-06-07 | 71 | 11d | 0d |  | Owner |
| 73 | 10.11.6 | Dev Services checks easement alignment against main line plans |  | 5d | 2007-06-08 | 2007-06-14 | 72 | 11d | 0d |  | CSU |
| 74 | 10.11.7 | FIMS reviews for closure and signature by proper landowner |  | 3d | 2007-06-15 | 2007-06-19 | 73 | 11d | 0d |  | CSU |
| 75 | 10.11.8 | Record easement and send notification to applicant |  | 2d | 2007-06-20 | 2007-06-21 | 74 | 11d | 7d |  | CSU |
| 76 | 11 | **Approval of Utility Service Plans** |  | 37d | 2007-05-23 | 2007-07-13 |  | 0d |  | as late as possible |  |
| 77 | 11.1 | Submit Utility Service Plans | milestone | 0d | 2007-05-23 | 2007-05-23 | 32, 40, 57 | 11d | 0d |  | Owner |
| 78 | 11.2 | Review and comment on USP |  | 8d | 2007-05-24 | 2007-06-04 | 77 | 11d | 0d |  | CSU |
| 79 | 11.3 | Revise and Resubmit USP |  | 5d | 2007-06-05 | 2007-06-11 | 78 | 11d | 0d |  | Owner |
| 80 | 11.4 | Review and comment on 2nd submittal USP |  | 8d | 2007-06-12 | 2007-06-21 | 79 | 11d | 0d |  | CSU |
| 81 | 11.5 | Submit Mylar for USP |  | 3d | 2007-06-22 | 2007-06-26 | 80 | 11d | 7d |  | Owner |
| 82 | 11.6 | Review and sign mylar for USP |  | 3d | 2007-07-06 | 2007-07-10 | 81, 45, 65 | 4d | 0d |  | CSU |
| 83 | 11.7 | Records delivered to CSU- Infrastructure Records |  | 3d | 2007-07-11 | 2007-07-13 | 82 | 28d | 0d |  | Owner |

| ID | WBS | Task | Type | Duration | Start | Finish | Predecessors | Total slack | Free slack | Constraint | Text1 |
| --- | --- | --- | --- | --- | --- | --- | --- | --- | --- | --- | --- |
| 84 | 12 | **Design on Dry Utility Plans** |  | 25d | 2007-07-06 | 2007-08-09 |  | 0d |  | as late as possible |  |
| 85 | 12.1 | Submit CAD drawing with final wet utility alignment to CSU- FIMS (UDCF) |  | 5d | 2007-07-06 | 2007-07-12 | 45, 65 | 54d | 0d |  | Owner |
| 86 | 12.2 | Submit Load Data and Extension Applications for Gas and Electric | milestone | 0d | 2007-07-12 | 2007-07-12 | 85 | 54d | 0d |  | Owner |
| 87 | 12.3 | Prepare and return dry utility design and Extension Contract |  | 20d | 2007-07-13 | 2007-08-09 | 86 | 54d | 26d |  | CSU |
| 88 | 13 | **Utility Construction** |  | 93d | 2007-07-13 | 2007-11-21 |  | 0d |  | as late as possible |  |
| 89 | 13.1 | 48 Hour notice given to Utilities before wastewater main line construction | milestone | 0d | 2007-07-13 | 2007-07-13 | 46, 83 | 28d | 0d |  | Owner |
| 90 | 13.2 | Install wastewater mainline and service stubs |  | 10d | 2007-07-18 | 2007-07-31 | 89FS+2d, 28 | 28d | 0d |  | Owner |
| 91 | 13.3 | 48 hour notice given to Utilities before water main line construction | milestone | 0d | 2007-07-31 | 2007-07-31 | 66, 90, 83 | 28d | 0d |  | Owner |
| 92 | 13.4 | Install water main line |  | 10d | 2007-08-03 | 2007-08-16 | 91FS+2d, 66, 83, 90, 28 | 28d | 0d |  | Owner |
| 93 | 13.5 | Install water service lines |  | 2d | 2007-08-17 | 2007-08-20 | 92 | 28d | 0d |  | Owner |
| 94 | 13.6 | Install storm sewer collection system |  | 10d | 2007-08-21 | 2007-09-03 | 93, 90 | 28d | 0d |  | Owner |
| 95 | 13.7 | Install curb and gutter |  | 10d | 2007-09-04 | 2007-09-17 | 94 | 28d | 0d |  | Owner |
| 96 | 13.8 | Pay Electric and Gas Extension Contract |  | 1d | 2007-09-17 | 2007-09-17 | 87 | 26d | 0d | as late as possible | Owner |
| 97 | 13.9 | FE releases job for scheduling |  | 1d | 2007-09-18 | 2007-09-18 | 96, 95 | 28d | 0d |  | CSU |
| 98 | 13.10 | CSU Com QC verifies the site is ready |  | 1d | 2007-09-19 | 2007-09-19 | 97 | 28d | 0d |  | CSU |
| 99 | 13.11 | Off-site gas and electric utilities installed |  | 15d | 2007-10-11 | 2007-10-31 | 98FS+15d | 28d | 0d |  | CSU |
| 100 | 13.12 | On-site gas installed (contingent on owner inspections) |  | 10d | 2007-11-01 | 2007-11-14 | 99 | 33d |  |  | Owner |
| 101 | 13.13 | On-site electric conduits installed (contingent on owner inspections) |  | 5d | 2007-11-01 | 2007-11-07 | 99 | 28d | 0d |  | Owner |
| 102 | 13.14 | Transformer set and wiring pulled |  | 5d | 2007-11-15 | 2007-11-21 | 101FS+5d | 28d |  |  | CSU |
| 103 | 14 | Prepare RBD Submittal (Architectural Drawings) |  | 40d | 2007-02-27 | 2007-04-23 | 14FF+15d | 30d | 0d |  | Owner |
| 104 | 15 | **Building Permit Approval** |  | 180d | 2007-04-23 | 2007-12-31 |  | 0d |  | as late as possible |  |
| 105 | 15.1 | Submit RBD Permit | milestone | 0d | 2007-04-23 | 2007-04-23 | 103 | 180d |  |  | Owner |
| 106 | 15.2 | 1st RBD review |  | 10d | 2007-04-24 | 2007-05-07 | 103 | 30d | 0d |  | RBD |
| 107 | 15.3 | Revision of RBD Drawings |  | 10d | 2007-05-08 | 2007-05-21 | 106 | 30d | 0d |  | Owner |
| 108 | 15.4 | 2nd review of RBD Drawings |  | 10d | 2007-05-22 | 2007-06-04 | 107 | 30d |  |  | RBD |
| 109 | 15.5 | Pay Fees and receive Utilities Service Contract | milestone | 0d | 2007-07-16 | 2007-07-16 | 65, 45, 82 | 4d | 0d | as late as possible | Owner |
| 110 | 15.6 | RBD Approval | milestone | 0d | 2007-07-16 | 2007-07-16 | 22, 108, 109 | 0d |  |  | RBD |
| 111 | 15.7 | Construct Building |  | 120d | 2007-07-17 | 2007-12-31 | 110 | 0d |  |  | Owner |
